# OSIRIS Infrastructure on K1 Rev 3 08 12 19

Schedule from MS Project, 2009-02-09 to 2013-02-25.
CARA

## Calendars

- Standard: Mon-Fri 08:00-12:00, 13:00-17:00; Sat-Sun off.

## Resources

| Resource | Group | Notes |
| --- | --- | --- |
| Senior Manager | WMKO |  |
| Science Lead | OSG | Typically academic appointment, only 1 or 2 months summer salary charged to project. |
| Science Team | OSG | Typically academic appointment, no direct labor charged to project. |
| Lead Mechanical Engineer | TSD |  |
| Mechanical Engineer 1 | TSD |  |
| Electronics Engineer 1 | TSD |  |
| Software Engineer 1 | SEG |  |
| AO System Engineer | OSG |  |
| Mechanical Technician 1 | OID |  |
| Mechanical Engineer 2 | TSD |  |
| Systems Engineer | OSG |  |
| Electronics Engineer 2 | TSD |  |
| Software Engineer 2 | SEG |  |
| Mechanical Technician 2 | OID |  |
| Electronics Technician 1 | OID |  |
| Electronics Technician 2 | OID |  |
| System Administrator | SEG |  |
| Facilities Engineer | OID |  |
| Mechanical Design Drafter | TSD |  |
| AO System Scientist | OSG |  |
| Laser Engineer | OID |  |
| Safety Officer | OID |  |
| Optics Engineer | OSG |  |
| Laser Technician | OID |  |
| Facilities Technician | OID |  |

## Schedule

| ID | WBS | Task | Type | Duration | Start | Finish | Predecessors | Total slack | Constraint | Resources | Work |
| --- | --- | --- | --- | --- | --- | --- | --- | --- | --- | --- | --- |
| 1 | 2 | **K2 Laser Removal** |  | 1055.5d? | 2009-02-09 | 2013-02-25 |  | 0d |  |  | 1949h |
| 2 | 2.0 | **Milestones** |  | 105.5d | 2012-10-01 | 2013-02-25 |  | 0d |  |  |  |
| 3 | 2.0.20 | K2 Laser goes Offline | milestone | 0d | 2012-10-01 | 2012-10-01 |  | 0d | start no earlier than 2012-10-01 |  |  |
| 4 | 1.1.2 | Phase 1 Removal of Equipment on Telescope | milestone | 0d | 2012-11-14 | 2012-11-14 | 13 | 73.25d | start no earlier than 2009-04-20 |  |  |
| 5 | 2.0.10 | Phase 2 Removal of Laser Room | milestone | 0d | 2013-01-15 | 2013-01-15 | 32 | 28.75d |  |  |  |
| 6 | 2.0.16 | Phase 3 Removal of Auxiliary Equipment and Software | milestone | 0d | 2013-02-22 | 2013-02-22 | 45 | 1d |  |  |  |
| 7 | 2.0.17 | Project Completion | milestone | 0d | 2013-02-25 | 2013-02-25 | 12 | 0d |  |  |  |
| 8 | 2.6 | **Planning and Review** |  | 1055.5d? | 2009-02-09 | 2013-02-25 |  | 0d |  |  | 194h |
| 9 | 2.6.22 | Preliminary Design Review Planning |  | 5d? | 2009-02-09 | 2009-02-13 |  | 1050.5d | start no earlier than 2009-02-09 | Systems Engineer | 40h |
| 10 | 1.2.2 | Detailed Design Review Planning |  | 5.5d | 2010-05-03 | 2010-05-10 |  | 730d | start no earlier than 2010-05-03 | Systems Engineer [22.7%]; Mechanical Engineer 1; Facilities Engineer; Laser Engineer; Software Engineer 1 | 50h |
| 11 | 2.6.1 | Final Detailed Review prior to dismantling; review safety issues |  | 8.8d | 2012-07-09 | 2012-07-19 | 3FS-60d | 156.7d | start no earlier than 2010-04-01 | Systems Engineer [22.7%]; Mechanical Engineer 1; Facilities Engineer; Laser Engineer; Software Engineer 1; Safety Officer | 80h |
| 12 | 2.6.23 | Final Review |  | 1d | 2013-02-22 | 2013-02-25 | 13, 32, 45 | 0d |  | Software Engineer 1 [50%]; Facilities Engineer [50%]; Electronics Engineer 1 [50%]; Safety Officer [50%]; Mechanical Engineer 1 [50%]; Systems Engineer [50%] | 24h |
| 13 | 2.7 | **Phase 1 Removal of Equipment on Telescope** |  | 32.25d? | 2012-10-01 | 2012-11-14 | 3 | 0d |  |  | 552h |
| 14 | 2.7.3 | **L4 Removal** |  | 4d? | 2012-10-01 | 2012-10-04 |  | 0d |  |  | 62h |
| 15 | 2.7.3.1 | Remove L4 Optic and store |  | 1d | 2012-10-01 | 2012-10-01 |  | 0d |  | Optics Engineer [50%]; Laser Technician [50%] | 8h |
| 16 | 2.7.3.2 | Remove Boresight Camera |  | 0.25d? | 2012-10-02 | 2012-10-02 | 15 | 0d |  | Electronics Technician 1 | 2h |
| 17 | 2.7.3.3 | Disconnect Motor and cable interfaces |  | 0.25d? | 2012-10-02 | 2012-10-02 | 16 | 0d |  | Electronics Technician 1 | 2h |
| 18 | 2.7.3.4 | Remove L4 Launch Tube and Support Brackets |  | 2.5d? | 2012-10-02 | 2012-10-04 | 17 | 0d |  | Electronics Technician 1; Mechanical Technician 1; Mechanical Technician 2 | 50h |
| 19 | 1.3.2 | **Laser Table and Auxiliary Electronics in Laser Enclosure** |  | 18.25d? | 2012-10-05 | 2012-10-31 | 14 | 0d |  |  | 290h |
| 20 | 1.3.2.1 | **Preparation** |  | 12.75d? | 2012-10-05 | 2012-10-23 |  | 0d |  |  | 172h |
| 21 | 1.3.2.1.1 | Packaging Preparation |  | 5d? | 2012-10-05 | 2012-10-11 |  | 0d |  | Facilities Technician | 40h |
| 22 | 1.3.2.1.2 | Remove laser dye and flush amp, preamp and dmo dye lines wiith de-I water and secure |  | 5d? | 2012-10-12 | 2012-10-18 | 21 | 0d |  | Laser Engineer; Laser Technician; Electronics Technician 2 | 96h |
| 23 | 1.3.2.1.3 | Disconnect Fiber and Secure on laser table |  | 0.5d? | 2012-10-19 | 2012-10-19 | 22 | 0d |  | Laser Technician | 4h |
| 24 | 1.3.2.1.4 | Disconnect Remaining Cabling and Secure |  | 1d? | 2012-10-19 | 2012-10-22 | 23 | 0d |  | Electronics Technician 1; Laser Technician | 12h |
| 25 | 1.3.2.1.5 | Remove Glycol Plumbing and Infrastructure Equipment |  | 1.25d? | 2012-10-22 | 2012-10-23 | 24 | 0d |  | Facilities Technician; Mechanical Technician 2 | 20h |
| 26 | 1.3.2.2 | Remove Auxiliary Electronics Equipment Unit and balance |  | 0.5d? | 2012-10-23 | 2012-10-24 | 25 | 0d |  | Mechanical Engineer 1; Mechanical Technician 1; Mechanical Technician 2; Electronics Technician 1 | 8h |
| 27 | 1.3.2.3 | Remove Laser Enclosure Top Section and balance |  | 1.25d? | 2012-10-24 | 2012-10-25 | 26 | 0d |  | Mechanical Engineer 1; Mechanical Technician 1; Mechanical Technician 2; Electronics Technician 1 | 30h |
| 28 | 1.3.2.4 | Remove Laser Table and balance |  | 1.25d? | 2012-10-25 | 2012-10-26 | 27 | 0d |  | Mechanical Engineer 1; Mechanical Technician 1; Mechanical Technician 2; Electronics Technician 1 | 30h |
| 29 | 1.3.2.5 | Re-install laser enclosure and balance |  | 2.5d? | 2012-10-26 | 2012-10-31 | 28 | 0d |  | Mechanical Engineer 1; Mechanical Technician 1; Mechanical Technician 2 | 50h |
| 30 | 2.7.22 | Transport, Tag, Store, and Disposal (if necessary) of Equipment |  | 5d? | 2012-10-31 | 2012-11-07 | 14, 19 | 0d |  | Facilities Technician; Mechanical Technician 1; Laser Technician; Electronics Technician 1 | 140h |
| 31 | 2.7.23 | Documentation |  | 5d? | 2012-11-07 | 2012-11-14 | 30 | 0d |  | Electronics Technician 1; Mechanical Design Drafter | 60h |

Notes:
- 4: The goal of this phase is to remove the equipment necessary to support NGAO. All equipment that can remain and not affect NGAO can remain. This phase is to allow NGAO to move forward.
- 5: This phase is to remove the laser room on the dome floor. However, it may be possible to turn this large room into a thermal controlled environment for experiments. It also has a system that can turn it into a clean room.
- 13: Shutdown is likely to be required for efficiency
- 14: This task will depend on the requirements for NGAO launch. Only parts of this unit may be needed to be remove.

| ID | WBS | Task | Duration | Start | Finish | Predecessors | Total slack | Free slack | Resources | Work |
| --- | --- | --- | --- | --- | --- | --- | --- | --- | --- | --- |
| 32 | 2.9 | **Phase 2 Removal of Laser Room** | 44.5d? | 2012-11-14 | 2013-01-15 | 13 | 0d |  |  | 726h |
| 33 | 2.9.11 | Packaging Preparaton | 5d? | 2012-11-14 | 2012-11-21 |  | 0d |  | Facilities Technician | 40h |
| 34 | 1.4.2 | **Remove External Interfaces** | 8.75d? | 2012-11-21 | 2012-12-03 | 33 | 5.75d |  |  | 80h |
| 35 | 1.4.2.1 | Disconnect Interfaces from Telescope (dye lines, cabling, fibersl) | 1.25d? | 2012-11-21 | 2012-11-22 |  | 5.75d | 0d | Electronics Technician 1; Laser Technician | 20h |
| 36 | 1.4.2.2 | Disconnect all glycol lines (instrument, facility); lines to ice wagon | 7.5d? | 2012-11-22 | 2012-12-03 | 35 | 5.75d |  | Facilities Technician | 60h |
| 37 | 1.4.3 | **Remove or move internal equipment** | 14.5d? | 2012-11-21 | 2012-12-11 | 33 | 0d |  |  | 266h |
| 38 | 1.4.3.1 | Move Auxiliary equipment for laser propagation into secured area | 2.5d? | 2012-11-21 | 2012-11-23 |  | 0d |  | Electronics Technician 1; System Administrator; Software Engineer 1 | 24h |
| 39 | 1.4.3.2 | Disconnect internal cabling | 2d? | 2012-11-23 | 2012-11-27 | 38 | 0d |  | Electronics Technician 1; Laser Technician; Electronics Engineer 1 | 42h |
| 40 | 1.4.3.3 | Remove equipment from laser room including dmo dye cabinet | 10d? | 2012-11-27 | 2012-12-11 | 39 | 0d |  | Electronics Technician 1; Laser Technician; Mechanical Technician 1 | 200h |
| 41 | 1.4.4 | Disconnect infrastructure; electrical power, conduits and HVAC | 10d? | 2012-12-11 | 2012-12-25 | 34, 37 | 0d |  | Facilities Technician | 80h |
| 42 | 2.9.7 | Disassemble laser room and remove | 5d | 2012-12-25 | 2013-01-01 | 41 | 0d |  | Facilities Technician; Mechanical Technician 1; Mechanical Technician 2; Mechanical Engineer 1 | 100h |
| 43 | 1.4.6 | Transport, Tag, Store, and Disposal (if necessary) of Equipment | 5d? | 2013-01-01 | 2013-01-08 | 42 | 0d |  | Facilities Technician; Laser Technician; Electronics Technician 1 | 120h |
| 44 | 2.9.10 | Documentation Cleanup and Correction | 5d? | 2013-01-08 | 2013-01-15 | 43 | 0d |  | Electronics Technician 1 | 40h |
| 45 | 2.11 | **Phase 3 Removal of Auxiliary Equipment and Software** | 27.75d? | 2013-01-15 | 2013-02-22 | 32 | 0d |  |  | 477h |
| 46 | 2.11.14 | Packaging Preparaton | 5d? | 2013-01-15 | 2013-01-22 |  | 15.75d | 0d | Facilities Technician | 40h |
| 47 | 1.5.2 | **AO Electronics** | 2.5d? | 2013-01-15 | 2013-01-18 |  | 0d |  |  | 40h |
| 48 | 1.5.2.1 | Remove and store Safety System PLC, laser 2, and electronics | 2.5d? | 2013-01-15 | 2013-01-18 |  | 0d |  | Electronics Engineer 1; Electronics Technician 1; Laser Technician | 40h |
| 49 | 2.11.10 | **Telescope Cabling** | 11.25d? | 2013-01-18 | 2013-02-04 | 47 | 0d |  |  | 150h |
| 50 | 1.5.3.1 | Remove cabling between Laser Enclosure and AO Enclosure | 7.5d? | 2013-01-18 | 2013-01-29 |  | 0d |  | Electronics Technician 1 | 60h |
| 51 | 2.11.10.1 | Remove Dye lines and Electronics cabling from telescope connected to laser room | 3.75d? | 2013-01-29 | 2013-02-04 | 50 | 0d |  | Electronics Technician 1; Mechanical Technician 1; Laser Technician | 90h |
| 52 | 1.5.4 | **Amp and Preamp Dye Cabinet** | 3.75d? | 2013-02-04 | 2013-02-08 | 49 | 0d |  |  | 40h |
| 53 | 1.5.4.1 | Remove Electrical From Cabinets | 1.25d? | 2013-02-04 | 2013-02-05 |  | 0d |  | Facilities Technician | 10h |
| 54 | 1.5.4.2 | Disconnect Cabinet | 1.25d? | 2013-02-05 | 2013-02-06 | 53 | 0d |  | Mechanical Technician 1; Mechanical Technician 2 | 20h |
| 55 | 1.5.4.3 | Ship, Pack and Store | 1.25d? | 2013-02-07 | 2013-02-08 | 54 | 0d |  | Facilities Technician | 10h |

Notes:
- 38: May have to keep k2 laser server or other computers operational until software references are cleaned up

| ID | WBS | Task | Duration | Start | Finish | Predecessors | Total slack | Free slack | Resources | Work |
| --- | --- | --- | --- | --- | --- | --- | --- | --- | --- | --- |
| 56 | 2.11.8 | **Software** | 7d? | 2013-01-22 | 2013-01-31 | 46 | 15.75d |  |  | 64h |
| 57 | 2.11.8.1 | Remove references in software that relies on original laser system | 5d? | 2013-01-22 | 2013-01-29 |  | 15.75d | 0d | Software Engineer 1; System Administrator | 40h |
| 58 | 2.11.8.2 | Disable computer server and verification subsystem operations | 1d? | 2013-01-29 | 2013-01-30 | 57 | 15.75d | 0d | System Administrator | 8h |
| 59 | 2.11.8.3 | Remove LTCS references | 1d? | 2013-01-30 | 2013-01-31 | 58 | 15.75d |  | Software Engineer 1; Electronics Technician 1 | 16h |
| 60 | 2.11.5 | **Auxiliary hardware** | 2.75d? | 2013-02-08 | 2013-02-12 | 52 | 0d |  |  | 63h |
| 61 | 2.11.5.1 | Remove k2laserpc and other computer equipment not necessary for NGAO | 0.25d? | 2013-02-08 | 2013-02-08 |  | 0d |  | Electronics Technician 1; System Administrator | 3h |
| 62 | 2.11.5.2 | Remove any equipment from mechanical room not necessary for NGAO | 2.5d? | 2013-02-08 | 2013-02-12 | 61 | 0d |  | Facilities Engineer; Mechanical Technician 1; Mechanical Technician 2 | 60h |
| 63 | 2.11.12 | Transport, Tag, Store, and Disposal (if necessary) of Equipment | 5d? | 2013-02-13 | 2013-02-19 | 52, 60 | 0d |  | Facilities Technician | 40h |
| 64 | 2.11.13 | Documentation Cleanup and Correction | 2.5d? | 2013-02-20 | 2013-02-22 | 63 | 0d |  | Electronics Technician 1; Facilities Engineer | 40h |
