# LLF System Project Plan

Schedule from MS Project, 2009-05-01 to 2010-01-29, A marks actual dates.
CARA

## Calendars

- Standard: Mon-Fri 08:00-12:00, 13:00-17:00; Sat-Sun off.

## Resources

| Resource |
| --- |
| Neyman |
| Chin |
| Stalcup |
| Bell |
| Mogensen |
| Wetherell |

## Schedule

| ID | WBS | Task | Type | Duration | Start | Finish | Predecessors | Complete | Remaining | Baseline start | Baseline finish | Baseline duration | Total slack | Free slack | Constraint | Resources | Work | Baseline cost |
| --- | --- | --- | --- | --- | --- | --- | --- | --- | --- | --- | --- | --- | --- | --- | --- | --- | --- | --- |
| 2 | 1 | **BC_v6 Laser Launch Facility (LLF)** |  | 161d? | 2009-05-01 | 2009-12-11 |  |  |  | 2009-04-01 | 2009-09-11 | 118d? | 35d |  |  |  | 664h | 29,550 |
| 3 | 1.1 | LLF Requirements & Interfaces |  | 41d? | 2009-05-01 | 2009-06-26 |  |  |  | 2009-04-01 | 2009-05-08 | 6d? | 155d |  | finish no earlier than 2009-06-26 | Neyman [3%]; Chin [3%] | 20h | 1,500 |
| 4 | 1.2 | LLF Optical Design |  | 86d? | 2009-05-01 | 2009-08-28 |  |  |  | 2009-05-01 | 2009-06-19 | 36d? | 110d |  | finish no earlier than 2009-08-28 | Neyman [2.9%]; Stalcup [29.1%] | 220h | 3,000 |
| 5 | 1.3 | LLF Launch Telescope Preliminary Design Contract (Resue KI?? MRI/NSF) |  | 55d? | 2009-05-18 | 2009-07-31 |  |  |  | 2009-05-18 | 2009-07-31 | 55d? | 130d |  | start no earlier than 2009-05-18 | Chin [5.5%] | 24h | 1,800 |
| 6 | 1.4 | LLF Mechanical Design |  | 38d? | 2009-08-10 | 2009-09-30 |  |  |  | 2009-06-01 | 2009-07-31 | 45d? | 87d |  | start no earlier than 2009-08-10 | Stalcup [6.6%]; Bell [49.3%]; Mogensen [16.4%] | 220h | 15,000 |
| 7 | 1.5 | LLF Electrical Design |  | 40d? | 2009-09-07 | 2009-10-30 |  |  |  | 2009-07-20 | 2009-08-28 | 30d? | 65d |  | start no earlier than 2009-09-07 | Stalcup [6.2%]; Chin [6.2%]; Wetherell [25%] | 120h | 7,500 |
| 8 | 1.6 | LLF Assembly, Alignment & Test Plans |  | 30d? | 2009-11-02 | 2009-12-11 |  |  |  | 2009-08-31 | 2009-09-11 | 10d? | 35d |  | finish no earlier than 2009-12-11 | Stalcup [20.8%]; Chin [4.2%] | 60h | 750 |
| 11 | 2 | **Laser Launch Facility (LLF)** |  | 186d? | 2009-05-15 A | 2010-01-29 |  |  | 185.24d? |  |  |  | 0d |  |  |  |  |  |
| 12 | 2.1 | LLF Design Complete | milestone | 0d | 2010-01-29 | 2010-01-29 | 116 |  |  |  |  |  | 0d |  |  |  |  |  |
| 13 | 2.2 | LTA Contract in Place | milestone | 0d | 2009-08-12 | 2009-08-12 | 127 |  |  |  |  |  | 122d |  |  |  |  |  |
| 14 | 2.3 | **LLF Requirements & Interfaces** |  | 98d? | 2009-05-15 A | 2009-09-29 |  |  | 97.52d? |  |  |  | 88d |  |  |  |  |  |
| 15 | 2.3.1 | **Requirements** |  | 16d? | 2009-05-15 A | 2009-06-05 |  | 69% | 5d? |  |  |  | 170d |  |  |  |  |  |
| 16 | 2.3.1.1 | TS reviews requirements and updates CN |  | 11d? | 2009-05-15 A | 2009-05-29 A |  | 100% |  |  |  |  |  |  | finish no earlier than 2009-05-29 |  |  |  |
| 17 | 2.3.1.2 | CN to update requirements |  | 5d | 2009-06-01 | 2009-06-05 | 16 |  |  |  |  |  | 170d |  |  |  |  |  |
| 18 | 2.3.2 | **Interface Document** |  | 87d? | 2009-06-01 | 2009-09-29 |  |  |  |  |  |  | 25d |  |  |  |  |  |
| 19 | 2.3.2.1 | CN to generate document based on N^2 |  | 10d? | 2009-06-01 | 2009-06-12 |  |  |  |  |  |  | 25d | 0d | start no earlier than 2009-06-01 |  |  |  |
| 20 | 2.3.2.2 | TS to update CN's Draft |  | 12d? | 2009-06-15 | 2009-06-30 | 19 |  |  |  |  |  | 25d | 0d | start no earlier than 2009-06-15 |  |  |  |
| 21 | 2.3.2.3 | **Internal to LGSF** |  | 60d | 2009-07-01 | 2009-09-22 | 20 |  |  |  |  |  | 25d | 0d |  |  |  |  |
| 22 | 2.3.2.3.1 | **Mechanical** |  | 60d | 2009-07-01 | 2009-09-22 |  |  |  |  |  |  | 25d |  |  |  |  |  |
| 23 | 2.3.2.3.1.1 | BGS to LTA Mechanical |  | 60d | 2009-07-01 | 2009-09-22 |  |  |  |  |  |  | 25d |  |  |  |  |  |
| 24 | 2.3.2.3.1.2 | BTOa,BTOb to BGS Mechanical |  | 60d | 2009-07-01 | 2009-09-22 |  |  |  |  |  |  | 25d |  |  |  |  |  |
| 25 | 2.3.2.3.1.3 | SWYa to BTOa Mechanical |  | 60d | 2009-07-01 | 2009-09-22 |  |  |  |  |  |  | 25d |  |  |  |  |  |
| 26 | 2.3.2.3.1.4 | SWYb to BTOb Mechanical |  | 60d | 2009-07-01 | 2009-09-22 |  |  |  |  |  |  | 25d |  |  |  |  |  |
| 27 | 2.3.2.3.1.5 | SWYa to LASa Mechanical |  | 60d | 2009-07-01 | 2009-09-22 |  |  |  |  |  |  | 25d |  |  |  |  |  |
| 28 | 2.3.2.3.1.6 | SWYb to LASb Mechanical |  | 60d | 2009-07-01 | 2009-09-22 |  |  |  |  |  |  | 25d |  |  |  |  |  |
| 29 | 2.3.2.3.1.7 | BTOa to Laser Enclosure Mechanical |  | 60d | 2009-07-01 | 2009-09-22 |  |  |  |  |  |  | 25d |  |  |  |  |  |
| 30 | 2.3.2.3.1.8 | BTOb to Laser Enclosure Mechanical |  | 60d | 2009-07-01 | 2009-09-22 |  |  |  |  |  |  | 25d |  |  |  |  |  |
| 31 | 2.3.2.3.1.9 | SWYa to Laser Enclosure Mechanical |  | 60d | 2009-07-01 | 2009-09-22 |  |  |  |  |  |  | 25d |  |  |  |  |  |
| 32 | 2.3.2.3.1.10 | SWYb to Laser Enclsoure Mechanical |  | 60d | 2009-07-01 | 2009-09-22 |  |  |  |  |  |  | 25d |  |  |  |  |  |

Notes:
- 2: TS

| ID | WBS | Task | Duration | Start | Finish | Predecessors | Total slack | Free slack |
| --- | --- | --- | --- | --- | --- | --- | --- | --- |
| 33 | 2.3.2.3.2 | **Optical** | 60d | 2009-07-01 | 2009-09-22 |  | 25d |  |
| 34 | 2.3.2.3.2.1 | SWYa to BTOa Optical | 60d | 2009-07-01 | 2009-09-22 |  | 25d |  |
| 35 | 2.3.2.3.2.2 | SWYb to BTOb Optical | 60d | 2009-07-01 | 2009-09-22 |  | 25d |  |
| 36 | 2.3.2.3.2.3 | BTOa to BGS Optical | 60d | 2009-07-01 | 2009-09-22 |  | 25d |  |
| 37 | 2.3.2.3.2.4 | BTOb to BGS Optical | 60d | 2009-07-01 | 2009-09-22 |  | 25d |  |
| 38 | 2.3.2.3.2.5 | BGS to LTA Optical | 60d | 2009-07-01 | 2009-09-22 |  | 25d |  |
| 39 | 2.3.2.3.2.6 | SWYa to LASa Optical | 60d | 2009-07-01 | 2009-09-22 |  | 25d |  |
| 40 | 2.3.2.3.2.7 | SWYb to LASb Optical | 60d | 2009-07-01 | 2009-09-22 |  | 25d |  |
| 41 | 2.3.2.3.3 | **Electronics** | 60d | 2009-07-01 | 2009-09-22 |  | 25d |  |
| 42 | 2.3.2.3.3.1 | **LLF to Laser Controller** | 60d | 2009-07-01 | 2009-09-22 |  | 25d |  |
| 43 | 2.3.2.3.3.1.1 | LTA to Laser Controller Electronic | 60d | 2009-07-01 | 2009-09-22 |  | 25d |  |
| 44 | 2.3.2.3.3.1.2 | BGS to Laser Controller Electronic | 60d | 2009-07-01 | 2009-09-22 |  | 25d |  |
| 45 | 2.3.2.3.3.1.3 | BTOa to Laser Controller Electronic | 60d | 2009-07-01 | 2009-09-22 |  | 25d |  |
| 46 | 2.3.2.3.3.1.4 | BTOb to Laser Controller Electronic | 60d | 2009-07-01 | 2009-09-22 |  | 25d |  |
| 47 | 2.3.2.3.3.1.5 | SWYa to Laser Controller Electronic | 60d | 2009-07-01 | 2009-09-22 |  | 25d |  |
| 48 | 2.3.2.3.3.1.6 | SWYb to Laser Controller Electronic | 60d | 2009-07-01 | 2009-09-22 |  | 25d |  |
| 49 | 2.3.2.3.3.2 | **LLF to Safety System** | 60d | 2009-07-01 | 2009-09-22 |  | 25d |  |
| 50 | 2.3.2.3.3.2.1 | BGS to SS Electronic | 60d | 2009-07-01 | 2009-09-22 |  | 25d |  |
| 51 | 2.3.2.3.3.2.2 | BTOa to SS Electronics | 60d | 2009-07-01 | 2009-09-22 |  | 25d |  |
| 52 | 2.3.2.3.3.2.3 | BTOb to SS Electronics | 60d | 2009-07-01 | 2009-09-22 |  | 25d |  |
| 53 | 2.3.2.3.3.2.4 | SWYa to SS Electronics | 60d | 2009-07-01 | 2009-09-22 |  | 25d |  |
| 54 | 2.3.2.3.3.2.5 | SWYb to SS Electronics | 60d | 2009-07-01 | 2009-09-22 |  | 25d |  |
| 55 | 2.3.2.4 | **External to LGSF** | 60d | 2009-07-01 | 2009-09-22 | 20 | 25d | 0d |
| 56 | 2.3.2.4.1 | **Mechanical** | 60d | 2009-07-01 | 2009-09-22 |  | 25d |  |
| 57 | 2.3.2.4.1.1 | LTA to f/15 module Mechanical | 60d | 2009-07-01 | 2009-09-22 |  | 25d |  |
| 58 | 2.3.2.4.1.2 | BGS to f/15 module Mechanical | 60d | 2009-07-01 | 2009-09-22 |  | 25d |  |
| 59 | 2.3.2.4.1.3 | BTOa to Telescope Mechanical | 60d | 2009-07-01 | 2009-09-22 |  | 25d |  |
| 60 | 2.3.2.4.1.4 | BTOb to Telescope Mechanical | 60d | 2009-07-01 | 2009-09-22 |  | 25d |  |
| 61 | 2.3.2.4.1.5 | BGS to facilites infrastructure (Glycol, Pneumatics, Electrical) | 60d | 2009-07-01 | 2009-09-22 |  | 25d |  |
| 62 | 2.3.2.4.1.6 | BTOa to facilites infrastructure (Glycol, Pneumatics, Electrical) | 60d | 2009-07-01 | 2009-09-22 |  | 25d |  |
| 63 | 2.3.2.4.1.7 | BTOb to facilites infrastructure (Glycol, Pneumatics, Electrical) | 60d | 2009-07-01 | 2009-09-22 |  | 25d |  |
| 64 | 2.3.2.4.1.8 | SWYa to facilites infrastructure (Glycol, Pneumatics, Electrical) | 60d | 2009-07-01 | 2009-09-22 |  | 25d |  |
| 65 | 2.3.2.4.1.9 | SWYb to facilites infrastructure (Glycol, Pneumatics, Electrical) | 60d | 2009-07-01 | 2009-09-22 |  | 25d |  |
| 66 | 2.3.2.5 | ICD Completion | 5d | 2009-09-23 | 2009-09-29 | 21, 55 | 25d | 15d |

| ID | WBS | Task | Type | Duration | Start | Finish | Predecessors | Total slack | Free slack | Constraint |
| --- | --- | --- | --- | --- | --- | --- | --- | --- | --- | --- |
| 67 | 2.4 | **LLF Optical Design** |  | 175d? | 2009-06-01 | 2010-01-29 |  | 0d |  |  |
| 68 | 2.4.1 | **Beam Generation System** |  | 65d? | 2009-06-01 | 2009-08-28 |  | 62d | 52d |  |
| 69 | 2.4.1.1 | Initial Design |  | 15d? | 2009-06-01 | 2009-06-19 |  | 67d | 0d | finish no earlier than 2009-06-19 |
| 70 | 2.4.1.2 | Zemax Model |  | 1d | 2009-06-22 | 2009-06-22 | 69 | 67d | 5d |  |
| 71 | 2.4.1.3 | Initial Presentation for Review |  | 1d? | 2009-06-30 | 2009-06-30 | 70 | 62d | 0d | start no earlier than 2009-06-30 |
| 72 | 2.4.1.4 | Electrical follow up with EE (Motion); Generate Req for EE |  | 5d | 2009-07-01 | 2009-07-07 | 71 | 62d | 0d |  |
| 73 | 2.4.1.5 | Mechanical Follow up with ME; Generate Req for ME |  | 5d | 2009-07-01 | 2009-07-07 | 71 | 62d | 0d |  |
| 74 | 2.4.1.6 | Optical Design; Drawings |  | 23d | 2009-07-08 | 2009-08-07 | 72, 73 | 62d | 0d |  |
| 75 | 2.4.1.7 | Electronics Design; Drawings |  | 23d | 2009-07-08 | 2009-08-07 | 72 | 62d | 0d |  |
| 76 | 2.4.1.8 | Mechanical Design; Drawings |  | 23d | 2009-07-08 | 2009-08-07 | 73 | 62d | 0d |  |
| 77 | 2.4.1.9 | **Documentation** |  | 15d | 2009-08-07 | 2009-08-28 |  | 62d |  |  |
| 78 | 2.4.1.9.1 | **Initial Draft of Design Documentation** |  | 0d | 2009-08-07 | 2009-08-07 |  | 62d | 0d |  |
| 79 | 2.4.1.9.1.1 | Optics | milestone | 0d | 2009-08-07 | 2009-08-07 | 74 | 62d |  |  |
| 80 | 2.4.1.9.1.2 | Electronics | milestone | 0d | 2009-08-07 | 2009-08-07 | 75 | 62d |  |  |
| 81 | 2.4.1.9.1.3 | Mechanical | milestone | 0d | 2009-08-07 | 2009-08-07 | 76 | 62d |  |  |
| 82 | 2.4.1.9.2 | Review of Initial Drafts |  | 10d | 2009-08-10 | 2009-08-21 | 78 | 62d | 0d |  |
| 83 | 2.4.1.9.3 | Final Draft of Design Documentation | milestone | 0d | 2009-08-28 | 2009-08-28 | 82FS+5d | 62d |  |  |
| 84 | 2.4.2 | **Beam Transport Optics** |  | 60d? | 2009-07-01 | 2009-09-22 |  | 10d |  |  |
| 85 | 2.4.2.1 | Initial Design |  | 15d? | 2009-07-01 | 2009-07-21 | 69SS+22d | 10d | 0d |  |
| 86 | 2.4.2.2 | Zemax Model |  | 1d | 2009-07-22 | 2009-07-22 | 85 | 45d | 0d |  |
| 87 | 2.4.2.3 | Initial Presentation for Review |  | 1d? | 2009-07-23 | 2009-07-23 | 86 | 45d | 0d | start no earlier than 2009-06-30 |
| 88 | 2.4.2.4 | Electrical follow up with EE (Motion); Generate Req for EE |  | 5d | 2009-07-24 | 2009-07-30 | 87 | 45d | 0d |  |
| 89 | 2.4.2.5 | Mechanical Follow up with ME; Generate Req for ME |  | 5d | 2009-07-24 | 2009-07-30 | 87 | 45d | 0d |  |
| 90 | 2.4.2.6 | Optical Design; Drawings |  | 23d | 2009-07-31 | 2009-09-01 | 88, 89 | 45d | 0d |  |
| 91 | 2.4.2.7 | Electronics Design; Drawings |  | 23d | 2009-07-31 | 2009-09-01 | 88 | 45d | 0d |  |
| 92 | 2.4.2.8 | Mechanical Design; Drawings |  | 23d | 2009-07-31 | 2009-09-01 | 89 | 45d | 0d |  |

| ID | WBS | Task | Type | Duration | Start | Finish | Predecessors | Total slack | Free slack | Constraint |
| --- | --- | --- | --- | --- | --- | --- | --- | --- | --- | --- |
| 93 | 2.4.2.9 | **Documentation** |  | 15d | 2009-09-01 | 2009-09-22 |  | 45d |  |  |
| 94 | 2.4.2.9.1 | **Initial Draft of Design Documentation** |  | 0d | 2009-09-01 | 2009-09-01 |  | 45d | 0d |  |
| 95 | 2.4.2.9.1.1 | Optics | milestone | 0d | 2009-09-01 | 2009-09-01 | 90 | 45d |  |  |
| 96 | 2.4.2.9.1.2 | Electronics | milestone | 0d | 2009-09-01 | 2009-09-01 | 91 | 45d |  |  |
| 97 | 2.4.2.9.1.3 | Mechanical | milestone | 0d | 2009-09-01 | 2009-09-01 | 92 | 45d |  |  |
| 98 | 2.4.2.9.2 | Review of Initial Drafts |  | 10d | 2009-09-02 | 2009-09-15 | 94 | 45d | 0d |  |
| 99 | 2.4.2.9.3 | Final Draft of Design Documentation | milestone | 0d | 2009-09-22 | 2009-09-22 | 98FS+5d | 45d |  |  |
| 100 | 2.4.3 | **Switch Yards** |  | 72d? | 2009-08-03 | 2009-11-10 |  | 10d | 0d |  |
| 101 | 2.4.3.1 | Initial Design |  | 15d? | 2009-08-03 | 2009-08-21 | 85SS+23d | 10d | 0d |  |
| 102 | 2.4.3.2 | Zemax Model |  | 1d | 2009-08-24 | 2009-08-24 | 101 | 10d | 0d |  |
| 103 | 2.4.3.3 | Initial Presentation for Review |  | 1d? | 2009-08-25 | 2009-08-25 | 102 | 10d | 0d | start no earlier than 2009-06-30 |
| 104 | 2.4.3.4 | Electrical follow up with EE (Motion); Generate Req for EE |  | 5d | 2009-08-26 | 2009-09-01 | 103 | 10d | 0d |  |
| 105 | 2.4.3.5 | Mechanical Follow up with ME; Generate Req for ME |  | 5d | 2009-08-26 | 2009-09-01 | 103 | 10d | 0d |  |
| 106 | 2.4.3.6 | Optical Design; Drawings |  | 23d | 2009-09-02 | 2009-10-02 | 104, 105 | 10d | 0d |  |
| 107 | 2.4.3.7 | Electronics Design; Drawings |  | 23d | 2009-09-02 | 2009-10-02 | 104 | 10d | 0d |  |
| 108 | 2.4.3.8 | Mechanical Design; Drawings |  | 23d | 2009-09-02 | 2009-10-02 | 105 | 25d | 0d |  |
| 109 | 2.4.3.9 | **Documentation** |  | 27d | 2009-10-05 | 2009-11-10 |  | 10d |  |  |
| 110 | 2.4.3.9.1 | **Initial Draft of Design Documentation** |  | 27d | 2009-10-05 | 2009-11-10 |  | 10d |  |  |
| 111 | 2.4.3.9.1.1 | Optics |  | 12d | 2009-10-05 | 2009-10-20 | 106 | 10d | 0d |  |
| 112 | 2.4.3.9.1.2 | Electronics |  | 12d | 2009-10-05 | 2009-10-20 | 107 | 10d | 0d |  |
| 113 | 2.4.3.9.1.3 | Mechanical |  | 12d | 2009-10-05 | 2009-10-20 | 108 | 25d |  |  |
| 114 | 2.4.3.9.1.4 | Alignment, Assembly and Test Plans |  | 5d | 2009-10-21 | 2009-10-27 | 111, 112, 66 | 10d | 0d |  |
| 115 | 2.4.3.9.1.5 | Review of Initial Drafts |  | 10d | 2009-10-28 | 2009-11-10 | 114 | 10d |  |  |
| 116 | 2.4.4 | **Final Draft of Design Documentation** |  | 58d | 2009-11-11 | 2010-01-29 |  | 0d |  |  |
| 117 | 2.4.4.1 | LLF Design Report |  | 12d | 2009-11-11 | 2009-11-26 | 68, 84, 100 | 10d | 0d |  |
| 118 | 2.4.4.2 | LLF Risk Report |  | 12d | 2009-11-27 | 2009-12-14 | 117 | 10d | 1d | finish no earlier than 2009-11-30 |
| 119 | 2.4.4.3 | LLF Budget Report |  | 12d | 2009-12-16 | 2009-12-31 | 118 | 9d |  | finish no earlier than 2009-12-31 |
| 120 | 2.4.4.4 | LLF Schedule |  | 12d | 2010-01-14 | 2010-01-29 | 119 | 0d |  | finish no earlier than 2010-01-29 |

| ID | WBS | Task | Type | Duration | Start | Finish | Predecessors | Total slack | Free slack | Constraint |
| --- | --- | --- | --- | --- | --- | --- | --- | --- | --- | --- |
| 121 | 2.5 | **LLF LTA Preliminary Contract In Place** |  | 32d | 2009-06-30 | 2009-08-12 |  | 122d |  |  |
| 122 | 2.5.1 | Approval of Control | milestone | 0d | 2009-06-30 | 2009-06-30 |  | 122d | 0d | start no earlier than 2009-06-30 |
| 123 | 2.5.2 | **First Round Contracts** |  | 22d | 2009-06-30 | 2009-07-29 |  | 122d |  |  |
| 124 | 2.5.2.1 | Contract Negotiations |  | 12d | 2009-06-30 | 2009-07-15 | 122 | 122d | 0d |  |
| 125 | 2.5.2.2 | Generation of Contract |  | 5d | 2009-07-16 | 2009-07-22 | 124 | 122d | 0d |  |
| 126 | 2.5.2.3 | Review of Contract by GA |  | 5d | 2009-07-23 | 2009-07-29 | 125 | 122d | 0d |  |
| 127 | 2.5.3 | **Final Round Contracts** |  | 10d | 2009-07-30 | 2009-08-12 |  | 122d | 0d |  |
| 128 | 2.5.3.1 | Generation of Contract |  | 5d | 2009-07-30 | 2009-08-05 | 126 | 122d | 0d |  |
| 129 | 2.5.3.2 | Signed Contract |  | 5d | 2009-08-06 | 2009-08-12 | 128 | 122d |  |  |
