# NGAO Laser Enclosure WBS5.1

Schedule from MS Project, 2010-10-01 to 2015-02-21, costs in $.
WMKO

## Calendars

- Standard: Mon-Fri 08:00-12:00, 13:00-17:00; Sat-Sun off. Exceptions (off unless hours are given): 2012-06-16 08:00-12:00, 13:00-17:00.

## Resources

| Resource | Group | Rate |
| --- | --- | --- |
| MRI Principal Investigator | E |  |
| MRI Subsystem Manager | E |  |
| MRI Optics Engineer | C |  |
| MRI Software Engineer | C |  |
| MRI Mechanical Engineer | C |  |
| MRI System Administrator | C |  |
| MRI AO System Engineer | C |  |
| MRI Electronics Engineer | C |  |
| MRI Electronics Technician | A |  |
| MRI Mechanical Technician | A |  |
| MRI Mechanical Designer | A |  |
| MRI AO Scientist | C |  |
| MRI Laser Engineer | C |  |
| MRI Laser Technician | A |  |
| MRI Laser Safety Officer | C |  |
| MRI Facilities Engineer | C |  |
| MRI Facilities Technician | A |  |
| MRI Instrumentation Manager | E |  |
| MRI System Engineer | C |  |
| MRI Mounting Frame |  | 4000 |
| MRI Laser Enclosure Panelling |  | 1000 |
| Temperature/Humidity Monitor |  | 1500 |
| MRI Summit Supervisor | C |  |
| MRI AO Software Engineer | C |  |
| MRI AO Electronics Technician | A |  |
| MRI Glycol Infrastructure |  | 3000 |
| Particulate Monitor |  | 3000 |
| HEPA Filtration |  | 500 |
| MRI Administrative Assistant | A |  |
| MRI Senior Managers | E |  |
| MRI Support Astronomer | C |  |
| MRI Electrical Infrastructure |  | 2500 |
| MRI Optical Mount and Window |  | 10000 |
| MRI Electronics Assemblies |  | 5000 |
| Optics Engineer |  |  |
| Mechanical Designer |  |  |
| Electronics Engineer |  |  |
| Software Engineer |  |  |
| Facilities Engineer |  |  |
| Subsystem Manager |  |  |
| AO Scientist |  |  |
| AO System Engineer |  |  |
| Mechanical Engineer |  |  |
| AO Software Engineer |  |  |
| System Engineer |  |  |
| Administrative Assistant |  |  |
| Principal Investigator |  |  |
| Senior Managers |  |  |
| Facilities Technician |  |  |
| Mechanical Technician |  |  |
| Electronics Technician |  |  |
| MRI Installation Hardware |  | 1000 |
| SYD Optical Mounts |  | 1000 |
| Instrumentation Manager |  |  |
| Support Astronomer |  |  |
| System Administrator |  |  |
| Laser Engineer |  |  |
| Laser Safety Officer |  |  |
| Summit Supervisor |  |  |
| AO Electronics Technician |  |  |
| Laser Technician |  |  |
| Installation Hardware |  | 1000 |

## Schedule

| ID | WBS | Task | Type | Duration | Start | Finish | Predecessors | Total slack | Free slack | Constraint | Resources | Work | Cost | Text1 |
| --- | --- | --- | --- | --- | --- | --- | --- | --- | --- | --- | --- | --- | --- | --- |
| 1 | 1 | **NGAO Laser Enclosure (WBS 5.1 DD/FSD, WBS 9.2 DC)** |  | 1147d? | 2010-10-01 | 2015-02-21 |  | 0d |  |  |  | 1488h | 33,500 |  |
| 2 | 1.1 | **Project Management & Reviews** |  | 872d | 2010-10-01 | 2014-02-01 |  | 275d |  |  |  |  |  |  |
| 3 | 1.1.1 | Project Start Date | milestone | 0d | 2010-10-01 | 2010-10-01 |  | 929d |  | start no earlier than 2010-10-01 |  |  |  |  |
| 4 | 1.1.2 | LE Activities ready for Summit | milestone | 0d | 2012-12-21 | 2012-12-21 | 48 | 347.58d |  |  |  |  |  |  |
| 5 | 1.1.3 | Laser #2 Removal Decision | milestone | 0d | 2013-02-01 | 2013-02-01 |  | 318d |  | start no earlier than 2013-02-01 |  |  |  |  |
| 6 | 1.1.4 | Laser #1 arrives at HQ | milestone | 0d | 2013-05-01 | 2013-05-01 |  | 255d |  | start no earlier than 2013-05-01 |  |  |  |  |
| 7 | 1.1.5 | Pre-Telescope Readiness Review | milestone | 0d | 2013-07-01 | 2013-07-01 |  | 212d |  | start no earlier than 2013-07-01 |  |  |  |  |
| 8 | 2.0.20 | K2 Laser goes Offline | milestone | 0d | 2013-08-01 | 2013-08-01 |  | 189d |  | start no earlier than 2013-08-01 |  |  |  |  |
| 9 | 1.1.7 | Keck 2 Laser Removed Phase A | milestone | 0d | 2013-08-30 | 2013-08-30 |  | 0d |  | start no earlier than 2013-08-30 |  |  |  |  |
| 10 | 1.1.8 | Operational Readiness Design Review | milestone | 0d | 2013-11-15 | 2013-11-15 | 67 | 330.32d |  | start no earlier than 2013-09-30 |  |  |  |  |
| 11 | 1.1.9 | Laser #1 Shared Risk Semester 14A | milestone | 0d | 2014-02-01 | 2014-02-01 |  | 57d |  | start no earlier than 2014-02-01 |  |  |  |  |
| 12 | 1.2 | **Detailed Design Phase** |  | 522d? | 2010-10-01 | 2012-09-28 |  | 216.3d |  |  |  | 549h |  | DD |
| 13 | 1.2.1 | DD Phase Management and Reporting |  | 20emo | 2010-10-01 | 2012-05-23 |  | 912.3d | 0d | start no earlier than 2010-10-01 | MRI Principal Investigator [0%]; MRI Subsystem Manager [0.3%]; MRI Administrative Assistant [0.1%] | 56h |  | DD |
| 14 | 1.2.2 | **Engineering Tasks** |  | 62d? | 2010-10-01 | 2010-12-27 |  | 449d | 0d |  |  | 333h |  | DD |
| 15 | 1.2.2.1 | **Opto-Mechanical** |  | 62d? | 2010-10-01 | 2010-12-27 |  | 449d |  |  |  | 200h |  | DD |
| 16 | 1.2.2.1.1 | Mounting Frame |  | 20d | 2010-10-01 | 2010-10-28 | 13SS | 449d | 0d |  | MRI Mechanical Engineer [25%]; MRI Mechanical Designer [25%] | 80h |  | DD |
| 17 | 1.2.2.1.2 | LE Mods for Install and Servicing |  | 20d | 2010-10-29 | 2010-11-25 | 16 | 449d | 0d |  | MRI Mechanical Engineer [12.5%]; MRI Mechanical Designer [12.5%] | 40h |  | DD |
| 18 | 1.2.2.1.3 | LE for BTO Interface |  | 19d | 2010-11-26 | 2010-12-22 | 17 | 449d | 0d |  | MRI Optics Engineer [15.8%]; MRI Mechanical Designer | 40h |  | DD |
| 19 | 1.2.2.1.4 | LE for SYD Interface |  | 3d? | 2010-12-23 | 2010-12-27 | 18 | 449d |  |  | Optics Engineer; Mechanical Designer | 40h |  | DD |
| 20 | 1.2.2.2 | **Infrastructure Support** |  | 22d | 2010-10-01 | 2010-11-01 |  | 489d |  |  |  | 40h |  | DD |
| 21 | 1.2.2.2.1 | Electrical Power |  | 10d | 2010-10-01 | 2010-10-14 |  | 489d | 0d |  | MRI Facilities Engineer [20%] | 16h |  | DD |
| 22 | 1.2.2.2.2 | Glycol Cooling Manifold |  | 12d | 2010-10-15 | 2010-11-01 | 21 | 489d |  |  | MRI Facilities Engineer [25%] | 24h |  | DD |
| 23 | 1.2.2.3 | **Electronics** |  | 20d | 2010-10-01 | 2010-10-28 |  | 491d |  |  |  | 93h |  | DD |
| 24 | 1.2.2.3.1 | Environmental: Temperature, Humidity, HEPA |  | 12d | 2010-10-01 | 2010-10-18 |  | 499d |  |  | Electronics Engineer [31.2%]; Software Engineer; Facilities Engineer | 53h |  | DD |
| 25 | 1.2.2.3.2 | Electronics Interface |  | 20d | 2010-10-01 | 2010-10-28 | 23 | 491d |  |  | MRI Electronics Engineer [25%] | 40h |  | DD |

| ID | WBS | Task | Duration | Start | Finish | Predecessors | Total slack | Free slack | Constraint | Resources | Work | Cost | Text1 |
| --- | --- | --- | --- | --- | --- | --- | --- | --- | --- | --- | --- | --- | --- |
| 26 | 1.2.3 | **System Engineering Tasks** | 460d | 2010-12-28 | 2012-09-28 | 14 | 449d |  |  |  | 160h |  | DD |
| 27 | 1.2.3.1 | Integration and Test Plans | 5d | 2010-12-28 | 2011-01-03 | 15, 20, 23, 25 | 449d | 0d |  | MRI Subsystem Manager; MRI Mechanical Engineer [50%]; MRI Electronics Engineer; MRI Software Engineer; MRI Facilities Engineer | 54h |  | DD |
| 28 | 1.2.3.2 | Documentation Preparation | 5d | 2011-01-04 | 2011-01-10 | 27 | 449d | 383d |  | MRI Subsystem Manager; MRI Administrative Assistant | 48h |  | DD |
| 29 | 1.2.3.3 | Detailed Design Review for NGAO Activities | 1d | 2012-06-28 | 2012-06-28 | 28 | 473d |  | start no earlier than 2012-06-28 | Subsystem Manager; AO Scientist; Optics Engineer; AO System Engineer; Mechanical Engineer; Software Engineer; AO Software Engineer; Electronics Engineer; System Engineer; Administrative Assistant; Principal Investigator; Senior Managers | 29h |  | DD |
| 30 | 1.2.3.4 | Detailed Design Review for MRI Activities | 1d | 2012-09-28 | 2012-09-28 | 28 | 0d |  | must finish on 2012-09-28 | MRI Subsystem Manager; MRI AO Scientist; MRI Optics Engineer; MRI AO System Engineer; MRI Mechanical Engineer; MRI Software Engineer; MRI AO Software Engineer; MRI Electronics Engineer; MRI System Engineer; MRI Administrative Assistant; MRI Principal Investigator; MRI Senior Managers | 29h |  | DD |
| 31 | 1.3 | **Full Scale Development Phase** | 501d | 2012-05-23 | 2014-04-23 |  | 218d |  |  |  | 476h | 31,500 | FSD |
| 32 | 1.3.1 | FSD Phase Management and Reporting | 23.33emo | 2012-05-23 | 2014-04-23 | 13 | 912.3d | 0d | start no earlier than 2010-10-01 | MRI Principal Investigator [0.1%]; MRI Subsystem Manager [0.3%]; MRI System Administrator [0%] | 51h |  | FSD |
| 33 | 1.3.2 | **Engineering Tasks** | 142.42d | 2012-05-23 | 2012-12-06 |  | 565.58d | 0d |  |  | 307h | 31,500 | FSD |
| 34 | 1.3.2.1 | **Opto-Mechanical** | 142.42d | 2012-05-23 | 2012-12-06 |  | 565.58d |  |  |  | 90h | 16,000 | FSD |
| 35 | 1.3.2.1.1 | Mounting Frame Fabrication | 66d | 2012-05-23 | 2012-08-21 | 32SS | 565.58d | 0d |  | MRI Mounting Frame; MRI Mechanical Engineer [3%]; MRI Mechanical Designer | 24h | 4,000 | FSD |
| 36 | 1.3.2.1.2 | LE Panels | 66d | 2012-08-22 | 2012-11-21 | 35 | 565.58d | 0d |  | MRI Laser Enclosure Panelling; MRI Mechanical Engineer [3%] | 16h | 1,000 | FSD |
| 37 | 1.3.2.1.3 | LE for BTO Interface | 5.21d | 2012-11-22 | 2012-11-29 | 36 | 565.58d | 0d |  | MRI Optical Mount and Window; MRI Optics Engineer; MRI Mechanical Technician [40%] | 25h | 10,000 | FSD |
| 38 | 1.3.2.1.4 | LE for SYD Interface | 5.21d | 2012-11-29 | 2012-12-06 | 37 | 565.58d |  |  | Optics Engineer; Mechanical Technician [40%]; SYD Optical Mounts | 25h | 1,000 | FSD |
| 39 | 1.3.2.2 | **Infrastructure** | 12d | 2012-05-23 | 2012-06-07 |  | 696d |  |  |  | 40h | 5,500 | FSD |
| 40 | 1.3.2.2.1 | Glycol Cooling Manifold | 6d | 2012-05-23 | 2012-05-30 | 32SS | 696d | 0d |  | MRI Glycol Infrastructure; MRI Facilities Technician [50%] | 24h | 3,000 | FSD |
| 41 | 1.3.2.2.2 | Electrical Components | 6d | 2012-05-31 | 2012-06-07 | 40 | 696d |  |  | MRI Facilities Technician [33.3%]; MRI Electrical Infrastructure | 16h | 2,500 | FSD |
| 42 | 1.3.2.3 | **Electronics** | 34.29d | 2012-05-23 | 2012-07-09 |  | 673.71d |  |  |  | 177h | 10,000 | FSD |
| 43 | 1.3.2.3.1 | Environmental: Temperature, Humidity, HEPA | 20d | 2012-05-23 | 2012-06-18 | 32SS | 673.71d | 0d |  | Electronics Engineer [50%]; Software Engineer [50%]; Particulate Monitor; Temperature/Humidity Monitor; HEPA Filtration; Facilities Technician | 128h | 5,000 | FSD |
| 44 | 1.3.2.3.2 | Electronics Interface | 14.29d | 2012-06-19 | 2012-07-09 | 43 | 673.71d |  |  | MRI Electronics Technician [35.7%]; MRI Electronics Assemblies; MRI Electronics Engineer | 49h | 5,000 | FSD |
| 45 | 1.3.3 | **System Engineering Tasks** | 11d | 2012-12-06 | 2012-12-21 | 33 | 565.58d |  |  |  | 118h |  | FSD |
| 46 | 1.3.3.1 | Integration and Test Plans | 5d | 2012-12-06 | 2012-12-13 |  | 347.58d | 0d |  | MRI Electronics Engineer [20%]; MRI Mechanical Engineer [20%]; MRI Facilities Engineer [20%]; MRI Subsystem Manager [20%]; MRI Optics Engineer [20%] | 40h |  | FSD |
| 47 | 1.3.3.2 | Documentation Preparation | 5d | 2012-12-13 | 2012-12-20 | 46 | 347.58d | 0d |  | MRI Subsystem Manager [40%]; MRI Administrative Assistant | 20h |  | FSD |
| 48 | 1.3.3.3 | Readiness Review for MRI | 1d | 2012-12-20 | 2012-12-21 | 47 | 347.58d | 0d |  | MRI Subsystem Manager; MRI AO Scientist; MRI Optics Engineer; MRI AO System Engineer; MRI Mechanical Engineer; MRI Software Engineer; MRI AO Software Engineer; MRI Electronics Engineer; MRI System Engineer; MRI Administrative Assistant; MRI Principal Investigator; MRI Senior Managers | 29h |  | FSD |
| 49 | 1.3.3.4 | Readiness Review for NGAO | 1d | 2012-12-20 | 2012-12-21 | 47 | 347.58d |  |  | Subsystem Manager; AO Scientist; Optics Engineer; AO System Engineer; Mechanical Engineer; Software Engineer; AO Software Engineer; Electronics Engineer; System Engineer; Administrative Assistant; Principal Investigator; Senior Managers | 29h |  | FSD |

| ID | WBS | Task | Duration | Start | Finish | Predecessors | Total slack | Free slack | Constraint | Resources | Work | Cost | Text1 |
| --- | --- | --- | --- | --- | --- | --- | --- | --- | --- | --- | --- | --- | --- |
| 50 | 1.4 | **Delivery and Commissioning Phase** | 386d | 2013-08-30 | 2015-02-21 |  | 0d |  |  |  | 463h | 2,000 | DI |
| 51 | 1.4.1 | DC Phase Management and Reporting | 18emo | 2013-08-30 | 2015-02-21 | 9 | 0d |  |  | MRI Subsystem Manager [0.3%]; MRI Administrative Assistant | 48h |  | DI |
| 52 | 1.4.2 | **Engineering Tasks** | 39.68d | 2013-08-30 | 2013-10-24 |  | 330.32d | 0d |  |  | 281h | 2,000 | DI |
| 53 | 1.4.2.1 | **Opto-Mechanical** | 20.18d | 2013-08-30 | 2013-09-27 |  | 330.32d | 0d |  |  | 149h | 1,000 | DI |
| 54 | 1.4.2.1.1 | Test Fit Mounting Frame | 5d | 2013-08-30 | 2013-09-05 | 9 | 330.32d | 0d |  | MRI Mechanical Engineer [40%]; MRI Mechanical Technician [200%] | 56h |  | DI |
| 55 | 1.4.2.1.2 | Modify LE Panels | 10.18d | 2013-09-06 | 2013-09-20 | 54 | 330.32d | 0d |  | MRI Mechanical Engineer [20%]; MRI Mechanical Technician [200%]; MRI Installation Hardware | 57h | 1,000 | DI |
| 56 | 1.4.2.1.3 | Install BTO Interface | 2.5d | 2013-09-20 | 2013-09-24 | 55 | 330.32d | 0d |  | MRI Optics Engineer [50%]; MRI Mechanical Technician [50%] | 18h |  | DI |
| 57 | 1.4.2.1.4 | Install Switchyard Interface | 2.5d | 2013-09-24 | 2013-09-27 | 56 | 330.32d |  |  | Optics Engineer [50%]; Mechanical Technician [50%] | 18h |  | DI |
| 58 | 1.4.2.2 | **Infrastructure** | 7.5d | 2013-09-27 | 2013-10-08 |  | 330.32d |  |  |  | 40h |  | DI |
| 59 | 1.4.2.2.1 | Install Glycol Cooling Manifold | 5d | 2013-09-27 | 2013-10-04 | 53 | 330.32d | 0d |  | MRI Facilities Technician [50%] | 20h |  | DI |
| 60 | 1.4.2.2.2 | Install Electrical Components | 2.5d | 2013-10-04 | 2013-10-08 | 59 | 330.32d | 0d |  | MRI Facilities Technician | 20h |  | DI |
| 61 | 1.4.2.3 | **Electronics** | 12d | 2013-10-08 | 2013-10-24 |  | 330.32d |  |  |  | 92h | 1,000 | DI |
| 62 | 1.4.2.3.1 | Install Environmental: Temperature, Humidity, HEPA | 5d | 2013-10-08 | 2013-10-15 | 60 | 330.32d | 0d |  | Electronics Engineer [50%]; Software Engineer [50%]; Facilities Technician; Electronics Technician; Installation Hardware | 56h | 1,000 | DI |
| 63 | 1.4.2.3.2 | Install Electronics Interface | 7d | 2013-10-15 | 2013-10-24 | 62 | 330.32d |  |  | MRI Electronics Technician [35.7%]; MRI Electronics Engineer | 36h |  | DI |
| 64 | 1.4.3 | **System Engineering Tasks** | 16d | 2013-10-24 | 2013-11-15 |  | 330.32d |  |  |  | 134h |  | DI |
| 65 | 1.4.3.1 | Integration and Test Report | 10d | 2013-10-24 | 2013-11-07 | 52 | 330.32d | 0d |  | Electronics Engineer [20%]; Mechanical Engineer [20%]; Facilities Engineer [20%]; Subsystem Manager [20%]; Optics Engineer [20%]; Software Engineer | 56h |  | DI |
| 66 | 1.4.3.2 | Documentation Preparation | 5d | 2013-11-07 | 2013-11-14 | 65 | 330.32d | 0d |  | Subsystem Manager [40%]; Administrative Assistant | 20h |  | DI |
| 67 | 1.4.3.3 | Operational Readiness Review for MRI | 1d | 2013-11-14 | 2013-11-15 | 66 | 330.32d | 0d | start no earlier than 2013-09-27 | MRI Subsystem Manager; MRI AO Scientist; MRI Optics Engineer; MRI AO System Engineer; MRI Mechanical Engineer; MRI Software Engineer; MRI AO Software Engineer; MRI Electronics Engineer; MRI System Engineer; MRI Administrative Assistant; MRI Principal Investigator; MRI Senior Managers | 29h |  | DI |
| 68 | 1.4.3.4 | Operational Readiness Review for NGAO | 1d | 2013-11-14 | 2013-11-15 | 66 | 330.32d |  | start no earlier than 2013-09-27 | Subsystem Manager; AO Scientist; Optics Engineer; AO System Engineer; Mechanical Engineer; Software Engineer; AO Software Engineer; Electronics Engineer; System Engineer; Administrative Assistant; Principal Investigator; Senior Managers | 29h |  | DI |
