# NGAO Laser 5.2

Schedule from MS Project, 2010-10-01 to 2015-05-08, costs in $.
WMKO

## Calendars

- Standard: Mon-Fri 08:00-12:00, 13:00-17:00; Sat-Sun off. Exceptions (off unless hours are given): 2012-06-16 08:00-12:00, 13:00-17:00.

## Resources

| Resource | Rate |
| --- | --- |
| MRI Principal Investigator |  |
| MRI Subsystem Manager |  |
| MRI Optics Engineer |  |
| MRI Software Engineer |  |
| MRI Mechanical Engineer |  |
| MRI System Administrator |  |
| MRI AO System Engineer |  |
| MRI Electronics Engineer |  |
| MRI Electronics Technician |  |
| MRI Mechanical Technician |  |
| MRI Mechanical Designer |  |
| MRI AO Scientist |  |
| MRI Laser Engineer |  |
| MRI Laser Technician |  |
| MRI Laser Safety Officer |  |
| MRI Facilities Engineer |  |
| MRI Facilities Technician |  |
| MRI Instrumentation Manager |  |
| MRI System Engineer |  |
| Laser Travel | 5000 |
| CS-LIC | 7500 |
| MRI Summit Supervisor |  |
| MRI AO Software Engineer |  |
| MRI AO Electronics Technician |  |
| Laser Test Equipment | 10000 |
| Clean Room Equipment | 1000 |
| Review Materials | 200 |
| Review Travel Local | 200 |
| MRI Administrative Assistant |  |
| MRI Senior Managers |  |
| Spotters Cost Per Night | 1800 |
| MRI Support Astronomer |  |
| Laser Removal Mechanical Components | 3000 |
| OM-BTO | 6000 |
| E-BTO | 3000 |
| E-Safety PLC | 10000 |
| M-Safety System | 3000 |
| OM-AOS | 4500 |
| E-AOS | 8000 |
| Laser Mounts | 8000 |
| Glycol System Components | 20000 |
| Laser Facility Electrical | 8000 |
| Laser HVAC | 5000 |
| Laser HQ Prep | 3000 |
| Laser Packing and Transport | 1500 |
| CS-Safety System | 2000 |
| Laser#1 Down Payment |  |
| Laser#1 Delivery Payment |  |
| Laser#1 Completion Payment |  |
| Laser #2-3 Down Payment |  |
| Laser #1 I&T Support Cost |  |
| Laser #2 Delivery Payment |  |
| Laser #2 Completion Payment |  |
| Laser #3 Delivery Payment |  |
| Laser #3 Completion Payment |  |
| Laser Installation Tools |  |
| Laser Support Contract |  |
| Laser Handling Tools |  |
| Laser#1 Custom and Duties |  |
| Laser Spares |  |
| Laser#2 Custom and Duties |  |
| Laser#3 Custom and Duties |  |
| Principal Investigator |  |
| Senior Managers |  |
| Instrumentation Manager |  |
| System Engineer |  |
| AO Scientist |  |
| AO System Engineer |  |
| Optics Engineer |  |
| AO Software Engineer |  |
| Software Engineer |  |
| Support Astronomer |  |
| Mechanical Engineer |  |
| Facilities Engineer |  |
| System Administrator |  |
| Electronics Engineer |  |
| Laser Engineer |  |
| Laser Safety Officer |  |
| Summit Supervisor |  |
| AO Electronics Technician |  |
| Electronics Technician |  |
| Mechanical Technician |  |
| Mechanical Designer |  |
| Laser Technician |  |
| Facilities Technician |  |
| Administrative Assistant |  |
| Subsystem Manager |  |

## Schedule

| ID | WBS | Task | Type | Duration | Start | Finish | Predecessors | Total slack | Free slack | Constraint | Resources | Work | Cost | Text1 |
| --- | --- | --- | --- | --- | --- | --- | --- | --- | --- | --- | --- | --- | --- | --- |
| 1 | 1 | **NGAO Lasers 5.2** |  | 1201d? | 2010-10-01 | 2015-05-08 |  | 0d |  | start no earlier than 2010-01-04 |  | 4240.44h | 67,500 |  |
| 2 | 1.1 | **Project Management & Reviews** |  | 880.83d | 2010-10-01 | 2014-02-13 |  | 320.17d |  |  |  |  |  |  |
| 3 | 1.1.1 | **Reviews & Milestones** |  | 880.83d | 2010-10-01 | 2014-02-13 |  | 320.17d |  |  |  |  |  |  |
| 4 | 1.1.1.1 | Project Start Date | milestone | 0d | 2010-10-01 | 2010-10-01 |  | 1201d |  | start no earlier than 2010-10-01 |  |  |  |  |
| 5 | 1.1.1.2 | Laser 2 Removal Decision | milestone | 0d | 2013-02-01 | 2013-02-01 |  | 590d |  | start no earlier than 2013-02-01 |  |  |  |  |
| 6 | 1.1.1.3 | Laser #1 Arrival | milestone | 0d | 2013-04-26 | 2013-04-26 | 45 | 529.17d |  | start no earlier than 2012-11-02 |  |  |  |  |
| 7 | 1.1.1.4 | Laser #1 Pre Telescope Review | milestone | 0d | 2013-06-27 | 2013-06-27 | 76 | 485.67d |  |  |  |  |  |  |
| 8 | 2.0.20 | K2 Laser goes Offline | milestone | 0d | 2013-08-01 | 2013-08-01 |  | 263.63d | 0d | start no earlier than 2013-08-01 |  |  |  |  |
| 9 | 1.1.1.6 | Laser #2&3 Arrival | milestone | 0d | 2013-12-30 | 2013-12-30 | 50 | 353.17d |  |  |  |  |  |  |
| 10 | 1.1.1.7 | Laser #2&3 Readiness at HQ | milestone | 0d | 2014-02-13 | 2014-02-13 | 82 | 320.17d |  |  |  |  |  |  |
| 11 | 1.2 | **Detailed Design Phase 5.2** |  | 392.83d? | 2010-10-01 | 2012-04-03 |  | 0d |  |  |  | 1412.96h | 30,000 | DD |
| 12 | 1.2.1 | DD Phase Reporting and Planning |  | 18emo | 2010-10-01 | 2012-03-24 |  | 0d |  | start no earlier than 2010-10-01 | MRI Subsystem Manager [1%]; MRI Administrative Assistant [0.2%] | 157.24h |  | DD |
| 13 | 1.2.2 | **Laser Procurement** |  | 392.83d? | 2010-10-01 | 2012-04-03 |  | 1.17d |  |  |  | 691.72h | 30,000 | DD |
| 14 | 1.2.2.1 | **Laser Management** |  | 13.33d | 2010-10-01 | 2010-10-20 |  | 1.17d |  |  |  | 80h |  | DD |
| 15 | 1.2.2.1.1 | Laser Vendor Selection | milestone | 0d | 2010-10-01 | 2010-10-01 | 12SS | 1.17d | 0d |  | MRI Instrumentation Manager [25%]; MRI Principal Investigator [25%] |  |  | DD |
| 16 | 1.2.2.1.2 | Laser Contracting |  | 13.33d | 2010-10-01 | 2010-10-20 | 15 | 1.17d | 0d | finish no earlier than 2010-02-15 | MRI Subsystem Manager [37.5%]; MRI Principal Investigator [37.5%]; Laser#1 Down Payment | 80h |  | DD |
| 17 | 1.2.2.2 | **Laser Phase 1 FDR** |  | 247.5d? | 2010-10-20 | 2011-09-30 |  | 1.17d |  |  |  | 393.8h | 10,000 | DD |
| 18 | 1.2.2.2.1 | Laser Detailed Design |  | 11.25mo | 2010-10-20 | 2011-09-30 | 16 | 1.17d | 0d | start no earlier than 2010-02-02 | MRI Instrumentation Manager [2%]; MRI Subsystem Manager [3%]; MRI System Engineer [2%]; MRI Laser Engineer [2%]; MRI Principal Investigator [2%] | 217.8h |  | DD |
| 19 | 1.2.2.2.2 | Laser Detailed Design Review | milestone | 5d? | 2011-09-23 | 2011-09-30 | 18FS-5d | 1.17d | 0d |  | Laser Travel [200%]; MRI Instrumentation Manager; MRI Subsystem Manager; MRI Software Engineer; MRI Principal Investigator; MRI System Engineer; MRI Laser Engineer | 176h | 10,000 | DD |
| 20 | 1.2.2.3 | **Laser Phase 2 PPU** |  | 132d | 2011-09-30 | 2012-04-03 |  | 1.17d |  |  |  | 217.92h | 20,000 | DD |
| 21 | 1.2.2.3.1 | PPU Fabrication |  | 6mo | 2011-09-30 | 2012-04-03 | 19 | 1.17d | 0d |  | MRI Instrumentation Manager [1%]; MRI Subsystem Manager [2%]; MRI Principal Investigator [2%]; MRI Software Engineer [1%]; Laser Travel [200%]; MRI Laser Engineer [1%] | 73.92h | 10,000 | DD |
| 22 | 1.2.2.3.2 | PPU Review |  | 5d | 2012-03-27 | 2012-04-03 | 21FS-5d | 1.17d | 0d |  | Laser Travel [200%]; MRI Instrumentation Manager; MRI Subsystem Manager; MRI Software Engineer; MRI Principal Investigator; MRI System Engineer; MRI Laser Engineer | 144h | 10,000 | DD |
| 23 | 1.2.3 | **Engineering Tasks** |  | 133.83d? | 2011-04-04 | 2011-10-07 |  | 930.17d |  |  |  | 508h |  |  |
| 24 | 1.2.3.1 | **Laser Control Software Design** |  | 32d | 2011-04-05 | 2011-05-18 |  | 1027d | 96.83d |  |  | 312h |  | DD |
| 25 | 1.2.3.1.1 | **Laser Interface Software** |  | 21d | 2011-04-05 | 2011-05-03 |  | 1027d |  |  |  | 216h |  | DD |
| 26 | 1.2.3.1.1.1 | LICS Requirements and Interfaces (ICD) |  | 6d | 2011-04-05 | 2011-04-12 | 12SS+6mo | 1027d | 0d |  | MRI System Engineer [33.3%]; MRI Software Engineer | 56h |  | DD |
| 27 | 1.2.3.1.1.2 | LICS Detailed Design, XML library, State Machines |  | 15d | 2011-04-13 | 2011-05-03 | 26 | 1027d | 0d |  | MRI System Engineer; MRI Software Engineer; MRI Laser Engineer | 160h |  | DD |

| ID | WBS | Task | Duration | Start | Finish | Predecessors | Total slack | Free slack | Constraint | Resources | Work | Cost | Text1 |
| --- | --- | --- | --- | --- | --- | --- | --- | --- | --- | --- | --- | --- | --- |
| 28 | 1.2.3.1.2 | **Laser Operational Software** | 11d | 2011-05-04 | 2011-05-18 |  | 1027d |  |  |  | 96h |  | DD |
| 29 | 1.2.3.1.2.1 | LOS Requirements and Interfaces (ICD) | 3d | 2011-05-04 | 2011-05-06 | 27 | 1027d | 0d |  | MRI System Engineer [33.3%]; MRI Software Engineer | 16h |  | DD |
| 30 | 1.2.3.1.2.2 | LOS Detailed Design, GUI design | 8d | 2011-05-06 | 2011-05-18 | 29 | 1027d |  |  | MRI System Engineer; MRI Software Engineer; MRI Laser Engineer | 80h |  | DD |
| 31 | 1.2.3.2 | **Laser Controller H/W Design** | 18d | 2011-04-04 | 2011-04-28 |  | 1041d | 110.83d |  |  | 76h |  | DD |
| 32 | 1.2.3.2.1 | **Laser Interface Controller** | 18d | 2011-04-04 | 2011-04-28 |  | 1041d |  |  |  | 76h |  | DD |
| 33 | 1.2.3.2.1.1 | LIC Requirements and Interfaces Review (ICD) | 10d | 2011-04-04 | 2011-04-18 | 12SS+6mo | 1041d | 0d | finish no earlier than 2010-10-01 | MRI System Engineer [10%]; MRI Software Engineer [50%]; MRI Electronics Engineer [50%]; MRI System Administrator [50%]; MRI AO System Engineer [50%]; MRI Laser Engineer [50%] | 28h |  | DD |
| 34 | 1.2.3.2.1.2 | LIC Design and Hardware Selection | 8d | 2011-04-18 | 2011-04-28 | 33 | 1041d |  |  | MRI System Engineer [25%]; MRI Software Engineer [25%]; MRI Electronics Engineer [25%]; MRI System Administrator [25%]; MRI AO System Engineer [25%] | 48h |  | DD |
| 35 | 1.2.3.3 | Laser I&T Test Plans | 5d? | 2011-09-30 | 2011-10-07 | 24, 31, 19 | 930.17d | 0d |  | MRI Laser Engineer; MRI Software Engineer; MRI Subsystem Manager | 120h |  | DD |
| 36 | 1.2.4 | Design Review and Documents | 5d | 2011-10-07 | 2011-10-14 | 35 | 930.17d |  |  | MRI System Engineer; MRI Software Engineer | 56h |  | DD |
| 37 | 1.3 | **Full Scale Implementation Phase 5.2** | 461.83d? | 2012-03-24 | 2013-12-30 |  | 0d |  |  |  | 1246.04h | 37,500 | FSD |
| 38 | 1.3.1 | FSD Phase Planning and Reporting | 20emo | 2012-03-24 | 2013-11-14 | 12 | 0d |  | finish no earlier than 2012-09-28 | MRI Subsystem Manager [0.7%]; MRI Administrative Assistant [0.3%] | 144.6h |  | FSD |
| 39 | 1.3.2 | **Engineering Tasks** | 455d? | 2012-04-03 | 2013-12-30 |  | 1.17d |  |  |  | 1045.44h | 37,500 |  |
| 40 | 1.3.2.1 | **Laser Procurement** | 455d | 2012-04-03 | 2013-12-30 |  | 1.17d |  |  |  | 685.44h | 30,000 | FSD |
| 41 | 1.3.2.1.1 | **Laser Phase 3 Unit #1 Delivery** | 279d | 2012-04-03 | 2013-04-26 |  | 1.17d |  |  |  | 382.72h | 15,000 | FSD |
| 42 | 1.3.2.1.1.1 | Laser #1 Fabrication | 12mo | 2012-04-03 | 2013-04-05 | 22 | 1.17d | 0d |  | MRI Software Engineer [1%]; MRI Laser Engineer [1%]; MRI Subsystem Manager [2%]; MRI Principal Investigator [2%] | 126.72h |  | FSD |
| 43 | 1.3.2.1.1.2 | Laser Training | 5d | 2013-03-22 | 2013-03-29 | 42FS-10d | 549.17d |  |  | MRI Laser Engineer [200%]; Laser Travel [50%] | 80h | 2,500 | FSD |
| 44 | 1.3.2.1.1.3 | Laser Factory Acceptance Review and Test | 5d | 2013-03-29 | 2013-04-12 | 42FS-5d | 1.17d | 0d | start no earlier than 2011-11-16 | MRI Instrumentation Manager [75%]; MRI Laser Engineer; Laser Travel [250%]; MRI Software Engineer; MRI Subsystem Manager; Laser#1 Delivery Payment; MRI Principal Investigator | 176h | 12,500 | FSD |
| 45 | 1.3.2.1.1.4 | Laser Unit #1 Shipping | 10d | 2013-04-12 | 2013-04-26 | 44 | 483.17d | 0d |  | Laser#1 Custom and Duties |  |  | FSD |
| 46 | 1.3.2.1.2 | **Laser Phase 3 Unit #2&3 Delivery** | 455d | 2012-04-03 | 2013-12-30 |  | 353.17d |  |  |  | 302.72h | 15,000 | FSD |
| 47 | 1.3.2.1.2.1 | Laser #2,3 Contract | 10d | 2012-04-03 | 2012-04-17 | 22 | 798.17d |  |  | Subsystem Manager [50%]; Principal Investigator [20%]; Laser #2-3 Down Payment | 56h |  | FSD |
| 48 | 1.3.2.1.2.2 | Laser #2&3 Fabrication | 8mo | 2013-04-12 | 2013-12-16 | 44 | 317.17d | 0d |  | Software Engineer [1%]; Laser Engineer [1%]; Subsystem Manager [5%]; Principal Investigator [2%] | 126.72h |  | FSD |
| 49 | 1.3.2.1.2.3 | Laser Factory Acceptance Review Test | 5d | 2013-12-09 | 2013-12-16 | 48FS-5d | 317.17d | 0d |  | Subsystem Manager; Laser Engineer; Laser #2 Delivery Payment; Laser #3 Delivery Payment; MRI Software Engineer; Laser Travel [300%] | 120h | 15,000 | FSD |
| 50 | 1.3.2.1.2.4 | Laser Unit #2&3 Shipment | 10d | 2013-12-16 | 2013-12-30 | 49 | 317.17d | 0d |  | Laser#2 Custom and Duties; Laser#3 Custom and Duties |  |  | FSD |
| 51 | 1.3.2.2 | **Laser Tooling** | 100d | 2012-04-03 | 2012-08-20 |  | 708.17d |  |  |  | 32h |  |  |
| 52 | 1.3.2.2.1 | Laser Support Equipment | 100d | 2012-04-03 | 2012-08-20 | 22 | 708.17d |  |  | Laser Installation Tools; MRI Laser Engineer [1%]; MRI Mechanical Engineer [1%] | 16h |  | FSD |
| 53 | 1.3.2.2.2 | Laser Handling Equipment | 100d | 2012-04-03 | 2012-08-20 | 22 | 708.17d |  |  | Laser Handling Tools; MRI Laser Engineer [2%] | 16h |  |  |

| ID | WBS | Task | Duration | Start | Finish | Predecessors | Total slack | Free slack | Constraint | Resources | Work | Cost | Text1 |
| --- | --- | --- | --- | --- | --- | --- | --- | --- | --- | --- | --- | --- | --- |
| 54 | 1.3.2.3 | **Laser Control Software Development** | 25d | 2012-09-25 | 2012-10-29 |  | 648.5d | 2d |  |  | 240h |  | FSD |
| 55 | 1.3.2.3.1 | **Laser Interface Software** | 15d | 2012-09-25 | 2012-10-15 | 38SS+6mo | 648.5d |  |  |  | 152h |  | FSD |
| 56 | 1.3.2.3.1.1 | LICS Full Scale Development | 15d | 2012-09-25 | 2012-10-15 |  | 648.5d | 0d | start no earlier than 2011-10-03 | MRI System Engineer; MRI Software Engineer; MRI Laser Engineer | 152h |  | FSD |
| 57 | 1.3.2.3.2 | **Laser Operational Software** | 10d | 2012-10-15 | 2012-10-29 |  | 648.5d |  |  |  | 88h |  | FSD |
| 58 | 1.3.2.3.2.1 | LOS Full Scale Development | 10d | 2012-10-15 | 2012-10-29 | 56 | 648.5d | 0d | start no earlier than 2011-10-03 | MRI System Engineer; MRI Software Engineer; MRI Laser Engineer | 88h |  | FSD |
| 59 | 1.3.2.4 | **Laser Controller H/W Development** | 2d | 2012-10-30 | 2012-10-31 |  | 648.5d | 0d |  |  | 28h | 7,500 | FSD |
| 60 | 1.3.2.4.1 | **Laser Interface Controller** | 2d | 2012-10-30 | 2012-10-31 |  | 648.5d |  |  |  | 28h | 7,500 | FSD |
| 61 | 1.3.2.4.1.1 | LIC Full Scale Development | 2d | 2012-10-30 | 2012-10-31 | 58 | 648.5d |  |  | MRI Electronics Engineer [50%]; MRI Electronics Technician [50%]; MRI System Administrator [50%]; MRI Software Engineer; CS-LIC | 28h | 7,500 | FSD |
| 62 | 1.3.2.5 | Laser I&T Test Plans | 2.5d? | 2012-11-01 | 2012-11-05 | 54, 59 | 648.5d | 0d |  | MRI Laser Engineer; MRI Software Engineer; MRI Subsystem Manager | 60h |  | FSD |
| 63 | 1.3.3 | Review and Documents | 5d | 2012-11-05 | 2012-11-12 | 62 | 648.5d |  |  | MRI System Engineer; MRI Software Engineer | 56h |  | FSD |
| 64 | 2.8 | **Delivery and Commissioning 5.2** | 536d? | 2013-04-18 | 2015-05-08 |  | 0d |  |  |  | 1581.44h |  | DI |
| 65 | 1.4.1 | DC Phase Planning and Reporting | 25emo | 2013-04-18 | 2015-05-08 | 38FS-7emo | 0d |  |  | MRI Subsystem Manager [0.8%]; MRI Administrative Assistant [0.2%] | 183.44h |  | DI |
| 66 | 1.4.2 | **Laboratory Integration & Test** | 212d? | 2013-04-26 | 2014-02-18 |  | 317.17d |  |  |  | 992h |  | DI |
| 67 | 1.4.2.1 | **Laser Unit #1** | 46d? | 2013-04-26 | 2013-07-01 |  | 483.17d |  |  |  | 608h |  | DI |
| 68 | 1.4.2.1.1 | **Laser Unit #1 Test and Verification** | 33d | 2013-04-26 | 2013-06-12 |  | 483.17d |  |  |  | 344h |  | DI |
| 69 | 1.4.2.1.1.1 | Setup Laser | 5d | 2013-04-26 | 2013-05-03 | 45 | 483.17d | 0d | start no earlier than 2012-01-04 | MRI System Engineer; MRI Mechanical Engineer; MRI Mechanical Technician; MRI Facilities Technician; MRI Laser Engineer; MRI Electronics Engineer | 128h |  | DI |
| 70 | 1.4.2.1.1.2 | Laser Unit #1 Base Acceptance Test | 5d | 2013-05-03 | 2013-05-10 | 69 | 483.17d | 0d |  | MRI Laser Engineer; MRI Subsystem Manager; Laser #1 I&T Support Cost | 56h |  | DI |
| 71 | 1.4.2.1.1.3 | Laser #1 Performance Measurements | 23d | 2013-05-10 | 2013-06-12 | 70 | 483.17d | 0d |  | MRI Laser Engineer [43.5%]; MRI Software Engineer [21.7%]; MRI Electronics Engineer [13%]; MRI System Engineer [8.7%] | 160h |  | DI |
| 72 | 1.4.2.1.2 | **Laser System Interface Testing** | 10d | 2013-06-12 | 2013-06-26 |  | 483.17d |  |  |  | 192h |  | DI |
| 73 | 1.4.2.1.2.1 | Laser Mounting on Frame | 1.5d | 2013-06-12 | 2013-06-14 | 71 | 494.67d |  | start no earlier than 2011-10-03 | MRI Summit Supervisor [166.7%]; MRI Mechanical Technician [666.7%]; MRI Mechanical Engineer [166.7%] | 40h |  | DI |
| 74 | 1.4.2.1.2.2 | Laser Interface Testing with Laser Controller at HQ | 5d | 2013-06-12 | 2013-06-19 | 71 | 483.17d | 0d |  | MRI Software Engineer; MRI Laser Engineer; MRI System Engineer | 96h |  | DI |
| 75 | 1.4.2.1.2.3 | Laser Operational Software Testing at HQ | 5d | 2013-06-19 | 2013-06-26 | 74 | 483.17d | 0d |  | MRI Software Engineer; MRI Laser Technician; MRI System Engineer | 56h |  | DI |
| 76 | 1.4.2.1.3 | Laser Unit #1 Readiness Review | 0.5d? | 2013-06-26 | 2013-06-27 | 75 | 483.17d | 0d |  | MRI Laser Engineer; MRI System Engineer; MRI Software Engineer; MRI Optics Engineer; MRI Subsystem Manager | 20h |  | DI |
| 77 | 1.4.2.1.4 | Laser System #1 Packing and Shipping | 2.5d | 2013-06-27 | 2013-07-01 | 76 | 483.17d |  |  | MRI Laser Engineer; MRI Electronics Engineer; MRI Electronics Technician | 52h |  | DI |

| ID | WBS | Task | Duration | Start | Finish | Predecessors | Total slack | Free slack | Constraint | Resources | Work | Text1 |
| --- | --- | --- | --- | --- | --- | --- | --- | --- | --- | --- | --- | --- |
| 78 | 1.4.2.2 | **Laser Unit #2,3** | 36d? | 2013-12-30 | 2014-02-18 |  | 317.17d |  |  |  | 384h | DI |
| 79 | 1.4.2.2.1 | **Laser Unit #2,3 Test and Verification** | 33d | 2013-12-30 | 2014-02-13 |  | 317.17d |  |  |  | 312h | DI |
| 80 | 1.4.2.2.1.1 | Setup Lasers | 5d | 2013-12-30 | 2014-01-06 | 50 | 317.17d | 0d | start no earlier than 2012-01-04 | System Engineer; Mechanical Engineer; Mechanical Technician; Facilities Technician; Laser Engineer; Electronics Engineer | 128h | DI |
| 81 | 1.4.2.2.1.2 | Laser Unit #2&3 Base Acceptance Test | 5d | 2014-01-06 | 2014-01-13 | 80 | 317.17d | 0d |  | MRI Laser Engineer; MRI Subsystem Manager; Laser #2 Completion Payment; Laser #3 Completion Payment | 56h | DI |
| 82 | 1.4.2.2.1.3 | Laser #2,3 Performance Measurements | 23d | 2014-01-13 | 2014-02-13 | 81 | 317.17d | 0d |  | Laser Engineer [43.5%]; Software Engineer [8.7%]; Electronics Engineer [8.7%]; System Engineer [8.7%] | 128h | DI |
| 83 | 1.4.2.2.2 | Laser Unit #2,3 Readiness Review | 0.5d? | 2014-02-13 | 2014-02-14 | 82 | 317.17d | 0d |  | Laser Engineer; System Engineer; Software Engineer; Optics Engineer; Subsystem Manager | 20h | DI |
| 84 | 1.4.2.2.3 | Laser System #3 Packing and Shipping | 2.5d | 2014-02-14 | 2014-02-18 | 83 | 317.17d |  |  | Laser Engineer; Electronics Engineer; Electronics Technician | 52h | DI |
| 85 | 1.4.3 | **Post Installation** | 327.83d? | 2014-02-03 | 2015-05-06 |  | 1.17d |  |  |  | 406h | DI |
| 86 | 1.4.3.1 | **Performance Capture (Laser Specific)** | 65.37d? | 2014-02-03 | 2014-05-05 |  | 263.63d |  |  |  | 286h | DI |
| 87 | 1.4.3.1.1 | Documentation | 5d | 2014-02-03 | 2014-02-07 | 8FS+6mo | 263.63d | 0d | finish no earlier than 2012-08-30 | MRI Electronics Engineer; MRI Software Engineer; MRI Laser Engineer; MRI Laser Safety Officer; Laser#1 Completion Payment | 130h | DI |
| 88 | 1.4.3.1.2 | Preventative Maintenance Program | 9.17d? | 2014-02-10 | 2014-02-21 | 87 | 263.63d | 0d |  | Laser Engineer; Laser Safety Officer | 88h | DI |
| 89 | 1.4.3.1.3 | Personnel Training | 51.2d | 2014-02-21 | 2014-05-05 | 88 | 263.63d |  | finish no earlier than 2012-08-30 | MRI Electronics Engineer [3.9%]; MRI Software Engineer [3.9%]; MRI Laser Engineer [3.9%]; MRI Laser Safety Officer; MRI Laser Technician | 68h | DI |
| 90 | 1.4.3.2 | **Laser Support Contract and Spares** | 10d | 2015-04-22 | 2015-05-06 |  | 1.17d |  |  |  | 120h | DI |
| 91 | 1.4.3.2.1 | Year 1 Laser Support Contract | 10d | 2015-04-22 | 2015-05-06 | 44FS+24mo | 1.17d |  |  | Laser Support Contract; MRI Subsystem Manager [50%]; MRI Laser Engineer | 60h | DI |
| 92 | 1.4.3.2.2 | Spares | 10d | 2015-04-22 | 2015-05-06 | 44FS+24mo | 1.17d |  |  | Laser Spares; MRI Subsystem Manager [50%]; MRI Laser Engineer | 60h | DI |
